# TECNOTREE DIGITAL NUMBER PORTABILITY

Schedule from MS Project, 2026-10-30 to 2028-05-26.

## Calendars

- CalendarioHabil-20230: Mon-Fri 08:00-12:00, 13:00-17:00; Sat-Sun off.

## Resources

| Resource |
| --- |
| Ingeniero de Implementación 01 |
| Ingeniero de Implementación 02 |

## Schedule

| ID | WBS | Task | Type | Duration | Start | Finish | Predecessors | Total slack | Free slack | Constraint | Resources | Work |
| --- | --- | --- | --- | --- | --- | --- | --- | --- | --- | --- | --- | --- |
| 1 | 1 | **Inicio** |  | 43d | 2026-10-30 | 2026-12-30 |  | 130d |  |  |  | 40h |
| 2 | 1.1 | **Iniciación** |  | 37d | 2026-10-30 | 2026-12-22 |  | 130d |  |  |  |  |
| 3 | 1.1.1 | Preparación de contrato |  | 35d | 2026-10-30 | 2026-12-18 |  | 130d | 0d | start no earlier than 2026-10-30 |  |  |
| 4 | 1.1.2 | Firma contratos y acuerdo de confidencialidad | milestone | 0d | 2026-12-18 | 2026-12-18 | 3 | 375d |  |  |  |  |
| 5 | 1.1.3 | Iniciación y Kick-Off |  | 1d | 2026-12-21 | 2026-12-22 | 3FS+1d | 130d | 0d |  |  |  |
| 6 | 1.2 | **Descubrimiento y Definciiones** |  | 5d | 2026-12-23 | 2026-12-30 |  | 130d |  |  |  | 32h |
| 7 | 1.2.1 | Análisis de ecosistema actual |  | 2d | 2026-12-23 | 2026-12-25 | 5FS+1d | 349d | 0d |  | Ingeniero de Implementación 01 [50%]; Ingeniero de Implementación 02 [50%] | 16h |
| 8 | 1.2.2 | Análisis de Seguridad de enlaces actuales |  | 2d | 2026-12-28 | 2026-12-30 | 7FS+1d | 349d | 0d |  | Ingeniero de Implementación 01 [50%]; Ingeniero de Implementación 02 [50%] | 16h |
| 9 | 1.2.3 | **Procesos de Negocio y Casos de Uso** |  | 1d | 2026-12-23 | 2026-12-24 |  | 130d |  |  |  |  |
| 10 | 1.2.3.1 | Definicion de Casos de Uso | milestone | 0d | 2026-12-23 | 2026-12-23 | 5FS+1d | 130d | 0d |  | Ingeniero de Implementación 02; Ingeniero de Implementación 01 |  |
| 11 | 1.2.3.2 | Priorizacion de Casos de Uso | milestone | 0d | 2026-12-24 | 2026-12-24 | 10FS+1d | 130d | 0d |  | Ingeniero de Implementación 01 [50%]; Ingeniero de Implementación 02 [50%] |  |
| 12 | 1.3 | Diseño de Ambientes y Arquitectura Objetivo | milestone | 0d | 2026-12-25 | 2026-12-25 | 11FS+1d | 130d | 0d |  | Ingeniero de Implementación 01 [50%]; Ingeniero de Implementación 02 [50%] |  |
| 13 | 1.4 | Elaboración de Plan de Proyecto |  | 1d | 2026-12-28 | 2026-12-29 | 12FS+1d | 130d | 0d |  | Ingeniero de Implementación 01 [50%]; Ingeniero de Implementación 02 [50%] | 8h |
| 14 | 1.5 | Aceptación de Plan de Proyecto | milestone | 0d | 2026-12-29 | 2026-12-29 | 13 | 367d | 0d |  | Ingeniero de Implementación 01 [50%]; Ingeniero de Implementación 02 [50%] |  |
| 15 | 2 | **Diseño de Solución** |  | 24d | 2026-12-28 | 2027-01-29 |  | 132d |  |  |  | 736h |
| 16 | 2.1 | Elaboración de Plan de Fortalezas, Oportunidades, Desafíos y Riesgos |  | 2d | 2026-12-28 | 2026-12-30 | 14FS-1d | 367d |  | start no earlier than 2026-12-28 | Ingeniero de Implementación 01 [50%]; Ingeniero de Implementación 02 [50%] | 16h |
| 17 | 2.2 | **Mejora de seguridad para los enlaces de comunicación** |  | 17d | 2026-12-31 | 2027-01-25 |  | 349d |  |  |  | 112h |
| 18 | 2.2.1 | Análisis de Brechas - GAP |  | 4d | 2026-12-31 | 2027-01-06 | 8FS+1d | 349d | 0d |  | Ingeniero de Implementación 01 [50%]; Ingeniero de Implementación 02 [50%] | 32h |
| 19 | 2.2.2 | Evaluación de riesgos |  | 4d | 2027-01-07 | 2027-01-13 | 18FS+1d | 349d | 0d |  | Ingeniero de Implementación 01 [50%]; Ingeniero de Implementación 02 [50%] | 32h |
| 20 | 2.2.3 | Elaboración de plan de mejoras de Seguridad |  | 4d | 2027-01-14 | 2027-01-20 | 19FS+1d | 349d | 0d |  | Ingeniero de Implementación 01 [50%]; Ingeniero de Implementación 02 [50%] | 32h |
| 21 | 2.2.4 | Alineamiento y Aprobación |  | 2d | 2027-01-21 | 2027-01-25 | 20FS+1d | 349d |  |  | Ingeniero de Implementación 01 [50%]; Ingeniero de Implementación 02 [50%] | 16h |
| 22 | 2.3 | **Diseño de Alto Nivel (HLD)** |  | 2d | 2026-12-30 | 2027-01-01 |  | 130d |  |  |  | 48h |
| 23 | 2.3.1 | HLD - Casos de Uso |  | 2d | 2026-12-30 | 2027-01-01 | 13FS+1d | 365d |  |  | Ingeniero de Implementación 01 [50%]; Ingeniero de Implementación 02 [50%] | 16h |
| 24 | 2.3.2 | HLD - Integraciones |  | 2d | 2026-12-30 | 2027-01-01 | 13FS+1d | 365d |  |  | Ingeniero de Implementación 01 [50%]; Ingeniero de Implementación 02 [50%] | 16h |
| 25 | 2.3.3 | HLD - Infrastructura |  | 2d | 2026-12-30 | 2027-01-01 | 13FS+1d | 130d | 0d |  | Ingeniero de Implementación 01 [50%]; Ingeniero de Implementación 02 [50%] | 16h |
| 26 | 2.3.4 | HLD - Documento Aprobado | milestone | 0d | 2027-01-01 | 2027-01-01 | 25 | 130d | 0d |  | Ingeniero de Implementación 01 [50%]; Ingeniero de Implementación 02 [50%] |  |

| ID | WBS | Task | Type | Duration | Start | Finish | Predecessors | Total slack | Free slack | Constraint | Resources | Work |
| --- | --- | --- | --- | --- | --- | --- | --- | --- | --- | --- | --- | --- |
| 27 | 2.4 | **Diseño de Bajo Nivel (LLD)** |  | 19d | 2027-01-04 | 2027-01-29 |  | 130d |  |  |  | 560h |
| 28 | 2.4.1 | Diseño de detallado de Infrastructura |  | 9d | 2027-01-04 | 2027-01-15 | 26FS+1d | 355d |  |  | Ingeniero de Implementación 01 [50%]; Ingeniero de Implementación 02 [50%] | 72h |
| 29 | 2.4.2 | Diagrama de red - Mapa de Comunicaciones |  | 9d | 2027-01-04 | 2027-01-15 | 26FS+1d | 355d |  |  | Ingeniero de Implementación 01 [50%]; Ingeniero de Implementación 02 [50%] | 72h |
| 30 | 2.4.3 | Diseño detallado de plataforma SIPN |  | 9d | 2027-01-04 | 2027-01-15 | 26FS+1d | 355d |  |  | Ingeniero de Implementación 01 [50%]; Ingeniero de Implementación 02 [50%] | 72h |
| 31 | 2.4.4 | LLD - Procesos y Casos de Uso |  | 19d | 2027-01-04 | 2027-01-29 | 26FS+1d | 130d | 0d |  | Ingeniero de Implementación 01 [50%]; Ingeniero de Implementación 02 [50%] | 152h |
| 32 | 2.4.5 | Diseño detallado de Integraciones |  | 9d | 2027-01-04 | 2027-01-15 | 26FS+1d | 355d |  |  | Ingeniero de Implementación 01 [50%]; Ingeniero de Implementación 02 [50%] | 72h |
| 33 | 2.4.6 | Elaboración de Manual de Interfaces |  | 15d | 2027-01-04 | 2027-01-25 | 26FS+1d | 349d | 0d |  | Ingeniero de Implementación 01 [50%]; Ingeniero de Implementación 02 [50%] | 120h |
| 34 | 2.4.7 | Manual de Interfaces: Especificaciones de APIs | milestone | 0d | 2027-01-25 | 2027-01-25 | 33 | 349d |  |  | Ingeniero de Implementación 01 [50%]; Ingeniero de Implementación 02 [50%] |  |
| 35 | 2.4.8 | LLD- Documento Aprobado | milestone | 0d | 2027-01-29 | 2027-01-29 | 31 | 130d | 0d |  | Ingeniero de Implementación 01 [50%]; Ingeniero de Implementación 02 [50%] |  |
| 36 | 3 | **Implementación** |  | 151d | 2027-02-01 | 2027-08-31 |  | 130d |  |  |  | 4616h |
| 37 | 3.1 | Despliegue de Infrastructura: DEV, UAT, PRD |  | 29d | 2027-02-01 | 2027-03-12 | 35FS+1d | 130d | 0d |  | Ingeniero de Implementación 01 [50%]; Ingeniero de Implementación 02 [50%] | 232h |
| 38 | 3.2 | Configuración de Conectivitdad + Security Hardening |  | 79d | 2027-02-01 | 2027-05-21 | 35FS+1d | 265d |  |  | Ingeniero de Implementación 01 [50%]; Ingeniero de Implementación 02 [50%] | 632h |
| 39 | 3.3 | **Instalación & Configuración de Plataforma SIPN** |  | 121d | 2027-03-15 | 2027-08-31 |  | 130d |  |  |  | 2728h |
| 40 | 3.3.1 | Front-end, Back-end & Database Setup |  | 29d | 2027-03-15 | 2027-04-23 | 37FS+1d | 130d | 0d |  | Ingeniero de Implementación 01 [50%]; Ingeniero de Implementación 02 [50%] | 232h |
| 41 | 3.3.2 | DBOD: Digital Business & Operations Platform |  | 29d | 2027-03-15 | 2027-04-23 | 37FS+1d | 195d | 0d |  | Ingeniero de Implementación 01 [50%]; Ingeniero de Implementación 02 [50%] | 232h |
| 42 | 3.3.3 | Platform Installed - OOTB | milestone | 0d | 2027-04-23 | 2027-04-23 | 41 | 195d | 0d |  | Ingeniero de Implementación 01 [50%]; Ingeniero de Implementación 02 [50%] |  |
| 43 | 3.3.4 | **Integrations** |  | 107d | 2027-04-02 | 2027-08-31 |  | 193d |  |  |  | 2112h |
| 44 | 3.3.4.1 | Integrations.: SUTEL,Operators,MNVOs |  | 79d | 2027-04-02 | 2027-07-22 | 35FS+45d | 193d | 0d |  | Ingeniero de Implementación 01 [50%]; Ingeniero de Implementación 02 [50%] | 632h |
| 45 | 3.3.4.2 | Establecimiento de comunicaciones SIPN con operadores / RP-Sutel / SGTM-Sutel / otras Sutel |  | 27d | 2027-07-23 | 2027-08-31 | 44FS+1d | 193d |  |  | Ingeniero de Implementación 01 [50%]; Ingeniero de Implementación 02 [50%] | 216h |
| 46 | 3.3.4.3 | NIP & Subscriber Authentication Integration |  | 79d | 2027-04-02 | 2027-07-22 | 35FS+45d | 221d |  |  | Ingeniero de Implementación 01 [50%]; Ingeniero de Implementación 02 [50%] | 632h |
| 47 | 3.3.4.4 | APIs/Interfaces Setup + Security Hardening |  | 79d | 2027-04-02 | 2027-07-22 | 35FS+45d | 221d |  |  | Ingeniero de Implementación 01 [50%]; Ingeniero de Implementación 02 [50%] | 632h |
| 48 | 3.3.4.5 | APIs/Interfaces Enabled | milestone | 0d | 2027-07-22 | 2027-07-22 | 44 | 221d |  |  | Ingeniero de Implementación 01 [50%]; Ingeniero de Implementación 02 [50%] |  |
| 49 | 3.3.5 | Customizations |  | 19d | 2027-04-27 | 2027-05-24 | 40FS+2d | 264d |  |  | Ingeniero de Implementación 01 [50%]; Ingeniero de Implementación 02 [50%] | 152h |
| 50 | 3.4 | **Use Cases Implementation** |  | 88d | 2027-04-27 | 2027-08-27 |  | 130d |  |  |  | 856h |
| 51 | 3.4.1 | Workflows:Portability, Syncro, Rollback |  | 88d | 2027-04-27 | 2027-08-27 | 40FS+2d | 130d | 0d |  | Ingeniero de Implementación 01 [50%]; Ingeniero de Implementación 02 [50%] | 704h |
| 52 | 3.4.2 | Generación de reportes estadísticos personalizados |  | 19d | 2027-04-27 | 2027-05-24 | 40FS+2d | 264d |  |  | Ingeniero de Implementación 01 [50%]; Ingeniero de Implementación 02 [50%] | 152h |
| 53 | 3.4.3 | Use Cases Implemented | milestone | 0d | 2027-08-27 | 2027-08-27 | 51 | 130d | 0d |  | Ingeniero de Implementación 01 [50%]; Ingeniero de Implementación 02 [50%] |  |
| 54 | 3.5 | Desarrollos, integración de la nueva ERPN con operadores/RP-Sutel | milestone | 0d | 2027-08-27 | 2027-08-27 |  | 195d |  | start no earlier than 2027-08-27 | Ingeniero de Implementación 01 [50%]; Ingeniero de Implementación 02 [50%] |  |
| 55 | 3.6 | Ajustes internos operadores con la nueva ERPN |  | 21d | 2027-08-02 | 2027-08-31 |  | 193d | 0d | start no earlier than 2027-08-02 | Ingeniero de Implementación 01 [50%]; Ingeniero de Implementación 02 [50%] | 168h |
| 56 | 3.7 | Ajustes internos operadores con la nueva ERPN | milestone | 0d | 2027-08-31 | 2027-08-31 | 55 | 193d |  |  | Ingeniero de Implementación 01 [50%]; Ingeniero de Implementación 02 [50%] |  |
| 57 | 3.8 | Entrega del SIPN | milestone | 0d | 2027-08-31 | 2027-08-31 |  | 193d |  | start no earlier than 2027-08-31 | Ingeniero de Implementación 01 [50%]; Ingeniero de Implementación 02 [50%] |  |

| ID | WBS | Task | Type | Duration | Start | Finish | Predecessors | Total slack | Free slack | Resources | Work |
| --- | --- | --- | --- | --- | --- | --- | --- | --- | --- | --- | --- |
| 58 | 4 | **Pruebas** |  | 64d | 2027-08-30 | 2027-11-26 |  | 130d |  |  | 520h |
| 59 | 4.1 | Preparación de Pruebas |  | 4d | 2027-08-30 | 2027-09-03 | 53FS+1d | 130d | 0d | Ingeniero de Implementación 01 [50%]; Ingeniero de Implementación 02 [50%] | 32h |
| 60 | 4.2 | Plan de pruebas | milestone | 0d | 2027-09-03 | 2027-09-03 | 59 | 130d | 0d | Ingeniero de Implementación 01 [50%]; Ingeniero de Implementación 02 [50%] |  |
| 61 | 4.3 | Pruebas No Funcionales + Seguridad y Hardening |  | 9d | 2027-09-06 | 2027-09-17 | 60FS+1d | 180d |  | Ingeniero de Implementación 01 [50%]; Ingeniero de Implementación 02 [50%] | 72h |
| 62 | 4.4 | **System Integration Test (SIT)** |  | 12d | 2027-09-06 | 2027-09-22 |  | 130d |  |  | 88h |
| 63 | 4.4.1 | Casos de Prueba: Portación estandar |  | 2d | 2027-09-06 | 2027-09-08 | 60FS+1d | 130d | 0d | Ingeniero de Implementación 01 [50%]; Ingeniero de Implementación 02 [50%] | 16h |
| 64 | 4.4.2 | Casos de Prueba: Ventana de cambio |  | 2d | 2027-09-09 | 2027-09-13 | 63FS+1d | 130d | 0d | Ingeniero de Implementación 01 [50%]; Ingeniero de Implementación 02 [50%] | 16h |
| 65 | 4.4.3 | Casos de Prueba: Consulta data historico |  | 2d | 2027-09-13 | 2027-09-15 | 64 | 130d | 0d | Ingeniero de Implementación 01 [50%]; Ingeniero de Implementación 02 [50%] | 16h |
| 66 | 4.4.4 | Casos de Prueba: Otros |  | 5d | 2027-09-15 | 2027-09-22 | 65 | 130d | 0d | Ingeniero de Implementación 01 [50%]; Ingeniero de Implementación 02 [50%] | 40h |
| 67 | 4.5 | **Operator Integration Testing (OIT)** |  | 14d | 2027-09-22 | 2027-10-12 |  | 130d |  |  | 104h |
| 68 | 4.5.1 | Casos de Prueba: Rechazo de Portabilidad |  | 2d | 2027-09-22 | 2027-09-24 | 66 | 130d | 0d | Ingeniero de Implementación 01 [50%]; Ingeniero de Implementación 02 [50%] | 16h |
| 69 | 4.5.2 | Casos de Prueba: Asynchronous timeout |  | 2d | 2027-09-24 | 2027-09-28 | 68 | 130d | 0d | Ingeniero de Implementación 01 [50%]; Ingeniero de Implementación 02 [50%] | 16h |
| 70 | 4.5.3 | Casos de Prueba: Otros |  | 9d | 2027-09-29 | 2027-10-12 | 69FS+1d | 130d | 0d | Ingeniero de Implementación 01 [50%]; Ingeniero de Implementación 02 [50%] | 72h |
| 71 | 4.5.4 | Reporte de Certification - Operadores | milestone | 0d | 2027-10-12 | 2027-10-12 | 70 | 163d |  | Ingeniero de Implementación 01 [50%]; Ingeniero de Implementación 02 [50%] |  |
| 72 | 4.6 | **Providers Integration Testing (PIT)** |  | 15d | 2027-10-13 | 2027-11-03 |  | 130d |  |  | 104h |
| 73 | 4.6.1 | Casos de Prueba: PIN Inválido |  | 2d | 2027-10-13 | 2027-10-15 | 70FS+1d | 130d | 0d | Ingeniero de Implementación 01 [50%]; Ingeniero de Implementación 02 [50%] | 16h |
| 74 | 4.6.2 | Casos de Prueba: Failover routing |  | 2d | 2027-10-18 | 2027-10-20 | 73FS+1d | 130d | 0d | Ingeniero de Implementación 01 [50%]; Ingeniero de Implementación 02 [50%] | 16h |
| 75 | 4.6.3 | Casos de Prueba: Otros |  | 9d | 2027-10-21 | 2027-11-03 | 74FS+1d | 130d | 0d | Ingeniero de Implementación 01 [50%]; Ingeniero de Implementación 02 [50%] | 72h |
| 76 | 4.6.4 | Reporte de Certification- Proveedores | milestone | 0d | 2027-11-03 | 2027-11-03 | 75 | 147d |  | Ingeniero de Implementación 01 [50%]; Ingeniero de Implementación 02 [50%] |  |
| 77 | 4.7 | **User Acceptance Test (UAT)** |  | 16d | 2027-11-04 | 2027-11-26 |  | 130d |  |  | 120h |
| 78 | 4.7.1 | Casos de Prueba: Portación estándar |  | 2d | 2027-11-04 | 2027-11-08 | 75FS+1d | 130d | 0d | Ingeniero de Implementación 01 [50%]; Ingeniero de Implementación 02 [50%] | 16h |
| 79 | 4.7.2 | Casos de Prueba: Ventana de cambio |  | 2d | 2027-11-08 | 2027-11-10 | 78 | 130d | 0d | Ingeniero de Implementación 01 [50%]; Ingeniero de Implementación 02 [50%] | 16h |
| 80 | 4.7.3 | Casos de Prueba: Consulta data historico |  | 2d | 2027-11-10 | 2027-11-12 | 79 | 130d | 0d | Ingeniero de Implementación 01 [50%]; Ingeniero de Implementación 02 [50%] | 16h |
| 81 | 4.7.4 | Casos de Prueba: Otros |  | 9d | 2027-11-15 | 2027-11-26 | 80FS+1d | 130d | 0d | Ingeniero de Implementación 01 [50%]; Ingeniero de Implementación 02 [50%] | 72h |
| 82 | 4.7.5 | Reporte de Pruebas | milestone | 0d | 2027-11-26 | 2027-11-26 | 81 | 130d | 0d | Ingeniero de Implementación 01 [50%]; Ingeniero de Implementación 02 [50%] |  |
| 83 | 4.8 | Pruebas Nueva ERPN-Operadores, RP-Sutel, SGTM-Sutel | milestone | 0d | 2027-11-26 | 2027-11-26 | 82 | 130d |  | Ingeniero de Implementación 01 [50%]; Ingeniero de Implementación 02 [50%] |  |

| ID | WBS | Task | Type | Duration | Start | Finish | Predecessors | Total slack | Free slack | Constraint | Resources | Work |
| --- | --- | --- | --- | --- | --- | --- | --- | --- | --- | --- | --- | --- |
| 84 | 5 | **Migration** |  | 82d | 2027-08-06 | 2027-11-30 |  | 128d |  |  |  | 624h |
| 85 | 5.1 | Assessment & Data Discovery |  | 9d | 2027-08-06 | 2027-08-19 |  | 128d | 0d | start no earlier than 2027-08-06 | Ingeniero de Implementación 01 [50%]; Ingeniero de Implementación 02 [50%] | 72h |
| 86 | 5.2 | Migration Design |  | 9d | 2027-08-20 | 2027-09-02 | 85FS+1d | 128d | 0d |  | Ingeniero de Implementación 01 [50%]; Ingeniero de Implementación 02 [50%] | 72h |
| 87 | 5.3 | ETL Development |  | 19d | 2027-09-03 | 2027-09-30 | 86FS+1d | 128d | 0d |  | Ingeniero de Implementación 01 [50%]; Ingeniero de Implementación 02 [50%] | 152h |
| 88 | 5.4 | Dry-Run |  | 20d | 2027-10-01 | 2027-10-29 | 87FS+1d | 128d | 0d |  | Ingeniero de Implementación 01 [50%]; Ingeniero de Implementación 02 [50%] | 160h |
| 89 | 5.5 | Procesos de migración de BDD números portados | milestone | 0d | 2027-10-29 | 2027-10-29 |  | 150d |  | start no earlier than 2027-10-29 | Ingeniero de Implementación 01 [50%]; Ingeniero de Implementación 02 [50%] |  |
| 90 | 5.6 | Cutover Migration |  | 21d | 2027-11-01 | 2027-11-30 | 88FS+1d | 128d | 0d |  | Ingeniero de Implementación 01 [50%]; Ingeniero de Implementación 02 [50%] | 168h |
| 91 | 5.7 | Migración parcial de BDD de números portados | milestone | 0d | 2027-11-12 | 2027-11-12 |  | 140d |  | start no earlier than 2027-11-12 | Ingeniero de Implementación 01 [50%]; Ingeniero de Implementación 02 [50%] |  |
| 92 | 5.8 | Migración final de BDD de números portados | milestone | 0d | 2027-11-30 | 2027-11-30 | 90 | 128d |  |  | Ingeniero de Implementación 01 [50%]; Ingeniero de Implementación 02 [50%] |  |
| 93 | 6 | **Salida Producción** |  | 284d | 2027-04-26 | 2028-05-26 |  | 0d |  |  |  | 1496h |
| 94 | 6.1 | Estrategia y Preparación |  | 2d | 2027-11-26 | 2027-11-30 |  | 85d | 0d | start no earlier than 2027-11-26 | Ingeniero de Implementación 01 [50%]; Ingeniero de Implementación 02 [50%] | 16h |
| 95 | 6.2 | Inicio de Operación ERPN | milestone | 0d | 2027-11-30 | 2027-11-30 | 94 | 85d | 0d |  | Ingeniero de Implementación 01 [50%]; Ingeniero de Implementación 02 [50%] |  |
| 96 | 6.3 | **Documentación y Entrenamiento** |  | 89d | 2027-04-26 | 2027-08-27 |  | 195d |  |  |  | 704h |
| 97 | 6.3.1 | Documentacion |  | 59d | 2027-04-26 | 2027-07-16 | 42FS+1d | 195d | 0d |  | Ingeniero de Implementación 01 [50%]; Ingeniero de Implementación 02 [50%] | 472h |
| 98 | 6.3.2 | Entrenamiento |  | 29d | 2027-07-19 | 2027-08-27 | 97FS+1d | 195d |  |  | Ingeniero de Implementación 01 [50%]; Ingeniero de Implementación 02 [50%] | 232h |
| 99 | 6.4 | Estabilización- Babysitting |  | 43d | 2027-11-30 | 2028-01-28 | 95 | 85d |  |  | Ingeniero de Implementación 01 [50%]; Ingeniero de Implementación 02 [50%] | 344h |
| 100 | 6.5 | **Propuesta de mejora, rediseño y optimización de portación** |  | 62d | 2028-03-01 | 2028-05-26 |  | 0d |  |  |  | 432h |
| 101 | 6.5.1 | Evaluación de estado actual |  | 9d | 2028-03-01 | 2028-03-14 |  | 0d |  | start no earlier than 2028-03-01 | Ingeniero de Implementación 01 [50%]; Ingeniero de Implementación 02 [50%] | 72h |
| 102 | 6.5.2 | Análisis de Brechas |  | 9d | 2028-03-15 | 2028-03-28 | 101FS+1d | 0d |  |  | Ingeniero de Implementación 01 [50%]; Ingeniero de Implementación 02 [50%] | 72h |
| 103 | 6.5.3 | Diseño Modelo Operativo Futuro |  | 9d | 2028-03-29 | 2028-04-11 | 102FS+1d | 0d |  |  | Ingeniero de Implementación 01 [50%]; Ingeniero de Implementación 02 [50%] | 72h |
| 104 | 6.5.4 | Proceso de Reingeniería |  | 9d | 2028-04-12 | 2028-04-25 | 103FS+1d | 0d |  |  | Ingeniero de Implementación 01 [50%]; Ingeniero de Implementación 02 [50%] | 72h |
| 105 | 6.5.5 | Nuevo Manual de Interfaces |  | 9d | 2028-04-28 | 2028-05-11 | 104FS+3d | 0d |  |  | Ingeniero de Implementación 01 [50%]; Ingeniero de Implementación 02 [50%] | 72h |
| 106 | 6.5.6 | Roadmap & Cronograma de implementación |  | 9d | 2028-05-15 | 2028-05-26 | 105FS+2d | 0d |  |  | Ingeniero de Implementación 01 [50%]; Ingeniero de Implementación 02 [50%] | 72h |
